# District4edit

Schedule from MS Project, 2016-02-10 to 2016-06-07.

## Calendars

- Standard: Mon-Fri 08:00-12:00, 13:00-17:00; Sat-Sun off.

## Resources

| Resource |
| --- |
| Project Manager |
| Attendees |
| Workers |
| City & County |
| Sparks Electrical PM |
| Sparks Electrical |
| Waterworks Plumbing PM |
| East Side Framing PM |
| Woodcraft Carpentry PM |
| Student Workers Manger |
| Dry wall PM |
| Dry wall |
| Woodcraft carpentry |
| City equipment movers PM |
| City equipment movers |
| Student Workers |
| Express Moving Company PM |
| Express Moving Company |
| East Side Framing |
| Waterworks Plumbing |

## Schedule

| ID | WBS | Task | Duration | Start | Finish | Predecessors | Total slack | Free slack | Resources | Work |
| --- | --- | --- | --- | --- | --- | --- | --- | --- | --- | --- |
| 1 | 1 | **District 4 Warehouse Move** | 85d | 2016-02-10 | 2016-06-07 |  | 0d |  |  | 1600h |
| 2 | 1.1 | **Project Kick-off** | 1d | 2016-02-10 | 2016-02-10 |  | 0d |  |  | 40h |
| 3 | 1.1.1 | Book location for meeting | 1d | 2016-02-10 | 2016-02-10 |  | 0d |  | Project Manager | 8h |
| 4 | 1.1.2 | Invite stakeholders | 1d | 2016-02-10 | 2016-02-10 | 3SS | 0d |  | Project Manager | 8h |
| 5 | 1.1.3 | Prepare presentation | 1d | 2016-02-10 | 2016-02-10 | 4FF | 0d |  | Project Manager | 8h |
| 6 | 1.1.4 | Conduct the meeting | 1d | 2016-02-10 | 2016-02-10 | 5SS | 12d |  | Attendees; Project Manager | 16h |
| 7 | 1.2 | **Project Documents** | 7d | 2016-02-11 | 2016-02-19 | 2 | 12d | 0d |  | 88h |
| 8 | 1.2.1 | Develop Charter/Scope | 1d | 2016-02-11 | 2016-02-11 |  | 12d | 0d | Project Manager | 8h |
| 9 | 1.2.2 | Develop WBS | 4d | 2016-02-12 | 2016-02-17 | 8 | 12d | 0d | Project Manager; Workers | 64h |
| 10 | 1.2.3 | Develop Project Plan | 1d | 2016-02-18 | 2016-02-18 | 9 | 12d | 0d | Project Manager | 8h |
| 11 | 1.2.4 | Develop Communication Plan | 1d | 2016-02-19 | 2016-02-19 | 10 | 12d |  | Project Manager | 8h |
| 12 | 1.3 | **Status Reports/Meetings** | 3d | 2016-02-22 | 2016-02-24 | 7 | 12d | 0d |  | 24h |
| 13 | 1.3.1 | Develop Status Report | 1d | 2016-02-22 | 2016-02-22 |  | 12d | 0d | Project Manager | 8h |
| 14 | 1.3.2 | Set schedule for team meetings | 1d | 2016-02-23 | 2016-02-23 | 13 | 12d | 0d | Project Manager | 8h |
| 15 | 1.3.3 | Set schedule for stakeholder meetings (To consider deadline extension) | 1d | 2016-02-24 | 2016-02-24 | 14 | 12d | 0d | Project Manager | 8h |
| 16 | 1.4 | **Initial Planning Meetings with Vendors** | 17d | 2016-02-25 | 2016-03-18 | 12 | 0d |  |  | 216h |
| 17 | 1.4.1 | Meet with Framing/Drywall | 1d | 2016-02-25 | 2016-02-25 | 15 | 12d | 0d | Project Manager; East Side Framing PM | 16h |
| 18 | 1.4.2 | Meet with Electrical | 1d | 2016-02-26 | 2016-02-26 | 17 | 12d | 0d | Project Manager; Sparks Electrical PM | 16h |
| 19 | 1.4.3 | Meet with Plumbing | 1d | 2016-02-29 | 2016-02-29 | 18 | 12d | 0d | Project Manager; Waterworks Plumbing PM | 16h |
| 20 | 1.4.4 | Meet with Finish Work | 1d | 2016-03-01 | 2016-03-01 | 19 | 12d | 0d | Project Manager; Woodcraft Carpentry PM | 16h |
| 21 | 1.4.5 | Meet with Student Workers | 1d | 2016-03-02 | 2016-03-02 | 20 | 12d |  | Project Manager; Student Workers Manger | 16h |
| 22 | 1.4.6 | **Workbenches** | 17d | 2016-02-25 | 2016-03-18 |  | 0d |  |  | 136h |
| 23 | 1.4.6.1 | Workbenches-Order Supplies | 2d | 2016-02-25 | 2016-02-26 |  | 0d |  | Student Workers Manger | 16h |
| 24 | 1.4.6.2 | Workbenches-Build | 12d | 2016-02-29 | 2016-03-15 | 23 | 0d |  | Student Workers | 96h |
| 25 | 1.4.6.3 | Workbenches-Quality inspection | 2d | 2016-03-16 | 2016-03-17 | 24 | 0d |  | City & County | 16h |
| 26 | 1.4.6.4 | Workbenches-Project Sign-off | 1d | 2016-03-18 | 2016-03-18 | 25 | 0d |  | Project Manager | 8h |

| ID | WBS | Task | Duration | Start | Finish | Predecessors | Total slack | Resources | Work |
| --- | --- | --- | --- | --- | --- | --- | --- | --- | --- |
| 27 | 1.5 | **Electrical Permits** | 10d | 2016-03-21 | 2016-04-01 | 16 | 0d |  | 80h |
| 28 | 1.5.1 | Obtain Electrical Permits | 10d | 2016-03-21 | 2016-04-01 | 16 | 0d | Sparks Electrical PM | 80h |
| 29 | 1.6 | **Plumbing Permits** | 10d | 2016-03-21 | 2016-04-01 | 16 | 0d |  | 80h |
| 30 | 1.6.1 | Obtain Plumbing Permits | 10d | 2016-03-21 | 2016-04-01 | 16 | 0d | Waterworks Plumbing PM | 80h |
| 31 | 1.7 | **Building Permits** | 10d | 2016-03-21 | 2016-04-01 | 16 | 0d |  | 160h |
| 32 | 1.7.1 | Obtain Building Permits | 10d | 2016-03-21 | 2016-04-01 | 16 | 0d | Dry wall PM; East Side Framing | 160h |
| 33 | 1.8 | **Framing** | 14d | 2016-04-04 | 2016-04-21 | 31 | 0d |  | 240h |
| 34 | 1.8.1 | Framing-Order Supplies | 1d | 2016-04-04 | 2016-04-04 | 32 | 0d | Dry wall PM; East Side Framing | 16h |
| 35 | 1.8.2 | Framing-Build | 12d | 2016-04-05 | 2016-04-20 | 34 | 0d | Dry wall; East Side Framing | 192h |
| 36 | 1.8.3 | Framing-Inspect | 3d | 2016-04-18 | 2016-04-20 | 35FF | 0d | City & County | 24h |
| 37 | 1.8.4 | Framing-Project Sign-off | 1d | 2016-04-21 | 2016-04-21 | 36 | 0d | Project Manager | 8h |
| 38 | 1.9 | **Electrical** | 10d | 2016-04-04 | 2016-04-15 | 27 | 0d |  | 96h |
| 39 | 1.9.1 | Electrical-Order Supplies | 1d | 2016-04-04 | 2016-04-04 | 28 | 0d | Sparks Electrical PM | 8h |
| 40 | 1.9.2 | Electrical-Install | 8d | 2016-04-05 | 2016-04-14 | 39 | 0d | Sparks Electrical | 64h |
| 41 | 1.9.3 | Electrical-Inspect | 2d | 2016-04-13 | 2016-04-14 | 40FF | 0d | City & County | 16h |
| 42 | 1.9.4 | Electrical-Project Sign-off | 1d | 2016-04-15 | 2016-04-15 | 41 | 0d | Project Manager | 8h |
| 43 | 1.10 | **Plumbing** | 13d | 2016-04-04 | 2016-04-20 | 29 | 0d |  | 104h |
| 44 | 1.10.1 | Plumbing-Order Supplies | 1d | 2016-04-04 | 2016-04-04 | 30 | 0d | Waterworks Plumbing PM | 8h |
| 45 | 1.10.2 | Plumbing-Install | 8d | 2016-04-05 | 2016-04-14 | 44 | 0d | Waterworks Plumbing | 64h |
| 46 | 1.10.3 | Plumbing-Inspect | 3d | 2016-04-15 | 2016-04-19 | 45 | 0d | City & County | 24h |
| 47 | 1.10.4 | Plumbing-Project Sign-off | 1d | 2016-04-20 | 2016-04-20 | 46 | 0d | Project Manager | 8h |
| 48 | 1.11 | **Drywall** | 17d | 2016-04-21 | 2016-05-13 | 43 | 0d |  | 240h |
| 49 | 1.11.1 | Drywall-Order Supplies | 1d | 2016-04-21 | 2016-04-21 | 47 | 0d | Dry wall PM; East Side Framing | 16h |
| 50 | 1.11.2 | Drywall-Install | 12d | 2016-04-22 | 2016-05-09 | 49 | 0d | Dry wall; East Side Framing | 192h |
| 51 | 1.11.3 | Drywall-Inspect | 3d | 2016-05-10 | 2016-05-12 | 50 | 0d | City & County | 24h |
| 52 | 1.11.4 | Drywall-Project Sign-off | 1d | 2016-05-13 | 2016-05-13 | 51 | 0d | Project Manager | 8h |

| ID | WBS | Task | Duration | Start | Finish | Predecessors | Total slack | Resources | Work |
| --- | --- | --- | --- | --- | --- | --- | --- | --- | --- |
| 53 | 1.12 | **Finish Work** | 17d | 2016-05-16 | 2016-06-07 | 48 | 0d |  | 136h |
| 54 | 1.12.1 | Finish-Order Supplies | 1d | 2016-05-16 | 2016-05-16 |  | 0d | Woodcraft Carpentry PM | 8h |
| 55 | 1.12.2 | Finish-Install | 12d | 2016-05-17 | 2016-06-01 | 54 | 0d | Woodcraft carpentry | 96h |
| 56 | 1.12.3 | Finish-Inspect | 3d | 2016-06-02 | 2016-06-06 | 55 | 0d | City & County | 24h |
| 57 | 1.12.4 | Finish-Project Sign-off | 1d | 2016-06-07 | 2016-06-07 | 56 | 0d | Project Manager | 8h |
| 58 | 1.13 | **Equipment Packing** | 5d | 2016-03-21 | 2016-03-25 | 22 | 0d |  | 40h |
| 59 | 1.13.1 | Pack production equipment | 2d | 2016-03-21 | 2016-03-22 |  | 0d | City equipment movers PM | 16h |
| 60 | 1.13.2 | Pack non-production equipment | 2d | 2016-03-23 | 2016-03-24 | 59 | 0d | City equipment movers | 16h |
| 61 | 1.13.3 | Project Sign-off | 1d | 2016-03-25 | 2016-03-25 | 60 | 0d | Project Manager | 8h |
| 62 | 1.14 | **Move** | 7d | 2016-03-28 | 2016-04-05 | 58 | 0d |  | 56h |
| 63 | 1.14.1 | Move production equipment | 3d | 2016-03-28 | 2016-03-30 |  | 0d | Express Moving Company PM | 24h |
| 64 | 1.14.2 | Move non-production equipment | 3d | 2016-03-31 | 2016-04-04 | 63 | 0d | Express Moving Company | 24h |
| 65 | 1.14.3 | Project Sign-off | 1d | 2016-04-05 | 2016-04-05 | 64 | 0d | Project Manager | 8h |
| 66 | 2 | **Procurement Closure** | 4d | 2016-04-06 | 2016-04-11 | 62 | 0d |  | 32h |
| 67 | 2.1 | Review contract work | 2d | 2016-04-06 | 2016-04-07 |  | 0d | Project Manager | 16h |
| 68 | 2.2 | Release contractors | 1d | 2016-04-08 | 2016-04-08 | 67 | 0d | Project Manager | 8h |
| 69 | 2.3 | Pay contractors | 1d | 2016-04-11 | 2016-04-11 | 68 | 0d | Project Manager | 8h |
| 70 | 3 | **Project Closure** | 3d | 2016-04-12 | 2016-04-14 | 66 | 0d |  | 24h |
| 71 | 3.1 | Final report | 1d | 2016-04-12 | 2016-04-12 |  | 0d | Project Manager | 8h |
| 72 | 3.2 | Archive documentation | 1d | 2016-04-13 | 2016-04-13 | 71 | 0d | Project Manager | 8h |
| 73 | 3.3 | Lessons Learned | 1d | 2016-04-14 | 2016-04-14 | 72 | 0d | Project Manager | 8h |
